# PLANNING PRO INDICE B_REMPLACE DES GROUPES DE PRO THERMIQUE_AEROPORT DE NICE

Schedule from MS Project, 2025-09-11 to 2028-03-01, 7 hours a day.

## Calendars

- Standard: Mon-Fri 09:00-12:00, 14:00-18:00; Sat-Sun off. Exceptions (off unless hours are given): 2027-12-20 to 2027-12-31 (congés hivernaux 2027).

## Schedule

| ID | WBS | Task | Type | Duration | Start | Finish | Predecessors | Total slack | Free slack | Constraint |
| --- | --- | --- | --- | --- | --- | --- | --- | --- | --- | --- |
| 1 | 1 | CONCEPTION SNIA / PRO - DCE |  | 60d | 2025-09-11 | 2025-12-03 |  | 0d |  | start no earlier than 2025-09-11 |
| 2 | 2 | RELECTURE PRO-DCE |  | 7d | 2025-12-04 | 2025-12-12 | 1 | 547d | 0d |  |
| 3 | 3 | FINALISATION DCE |  | 15d | 2025-12-15 | 2026-01-02 | 2 | 553d |  |  |
| 4 | 4 | VALIDATION DSNA |  | 21d | 2025-12-15 | 2026-01-12 | 2 | 547d |  |  |
| 5 | 5 | REDACTION DE LA PARTIE ADMINISTRATIVE DU DCE |  | 21d | 2025-12-04 | 2026-01-01 | 1 | 0d |  |  |
| 6 | 6 | RELECTURE POLE ACHAT |  | 15d | 2026-01-02 | 2026-01-22 | 5 | 539d |  |  |
| 7 | 7 | AVIS RMA |  | 21d | 2026-01-16 | 2026-02-13 | 5FS+10d | 0d |  |  |
| 8 | 8 | PUBLICATION DU DCE |  | 90ed | 2026-02-13 | 2026-05-14 | 7 | 2.14d |  |  |
| 9 | 9 | ANALYSE DES CANDIDATURES |  | 10d | 2026-05-15 | 2026-05-28 | 8 | 0d |  |  |
| 10 | 10 | DEMANDE DE COMPLEMENT DES CANDIDATURES |  | 10d | 2026-05-29 | 2026-06-11 | 9 | 0d |  |  |
| 11 | 11 | ANALYSE DES OFFRES |  | 20d | 2026-06-12 | 2026-07-09 | 10 | 0d |  |  |
| 12 | 12 | NEGOCIATION |  | 20d | 2026-07-10 | 2026-08-06 | 11 | 0d |  |  |
| 13 | 13 | ANALYSE DES OFFRES NEGOCIEES |  | 7d | 2026-08-07 | 2026-08-17 | 12 | 0d |  |  |
| 14 | 14 | RELECTURE POLE ACHAT |  | 15d | 2026-08-18 | 2026-09-07 | 13 | 0d |  |  |
| 15 | 15 | VISA CB & INFORMATION AUX NON-RETENUS |  | 21d | 2026-09-08 | 2026-10-06 | 14 | 0d |  |  |
| 16 | 16 | Engagement juridique |  | 7d | 2026-10-07 | 2026-10-15 | 15 | 0d |  |  |
| 17 | 17 | Notification marché | milestone | 0d | 2026-10-15 | 2026-10-15 | 16 | 0d |  |  |
| 18 | 18 | **Délai global de 16 mois y compris la période de préparation de 3 mois et périodes AOR** |  | 349d | 2026-10-15 | 2028-03-01 |  | 0d |  |  |
| 19 | 18.1 | PERIODE 1_TRAVAUX STRUCTURELS / COUVERTURE_CVC INITIAL_3,7 MOIS |  | 78d | 2027-01-08 | 2027-04-27 | 21 | 4d | 0d |  |
| 20 | 18.2 | Os n°1 | milestone | 0d | 2026-10-15 | 2026-10-15 | 17 | 0d |  |  |
| 21 | 18.3 | Période de préparation (études complémentaires, installation de la base vie, Etat des lieux avant travaux, protection du monte charge, gestion des accès, validation PIC, PEO, FT, échantillons). 3 mois |  | 60d | 2026-10-16 | 2027-01-07 | 20 | 0d |  |  |
| 22 | 18.4 | Dossier levage à monter et à faire valider avec la tour de contrôle et autorisation grue de levage à valider avec la DGAC |  | 30d | 2026-11-27 | 2027-01-07 | 21SS+30d | 0d |  |  |
| 23 | 18.5 | OS Démarrage travaux | milestone | 0d | 2027-01-07 | 2027-01-07 | 22 | 0d |  |  |
| 24 | 18.6 | Consignation CFO / CFA et réseaux d'une manière générale de la zone ou on va faire de la démolition sur NBT | milestone | 0d | 2027-01-07 | 2027-01-07 | 23 | 289d |  |  |

| ID | WBS | Task | Duration | Start | Finish | Predecessors | Total slack | Free slack |
| --- | --- | --- | --- | --- | --- | --- | --- | --- |
| 25 | 18.7 | **LOT 2 : Couverture (isolation – étanchéité)** | 57d | 2026-12-10 | 2027-02-26 |  | 21d |  |
| 26 | 18.7.1 | Mise en sécurité (type protection collective) de la toiture terrasse du Nouveau Bloc Technique (NBC) | 21d | 2026-12-10 | 2027-01-07 | 23SF | 289d |  |
| 27 | 18.7.2 | Retrait de la protection lourde | 5d | 2027-01-08 | 2027-01-14 | 23 | 0d |  |
| 28 | 18.7.3 | Dépose des couvertines / étanchéité existante (258m²) / isolation / relevés / joints de fractionnement / plots / GC / éléments singuliers | 10d | 2027-01-15 | 2027-01-28 | 27 | 0d |  |
| 29 | 18.7.4 | Maintien d'une étanchéité provisoire pendant la réalisation et séchage plots bétons et en attendant l'étanchéité définitive | 21d | 2027-01-29 | 2027-02-26 | 38SS | 253d |  |
| 30 | 18.7.5 | Pose pare-vapeur /relevé / isolation thermique / membrane d'étanchéité / couvertines / naissances d'EP / joint de fractionnement / éléments singuliers / Points d'ancrage (attention 2 équipes de sollicitées ici - 4 ouvriers min.) / commencer par local tech | 10d | 2027-02-15 | 2027-02-26 | 39FF+1d | 0d |  |
| 31 | 18.8 | **LOT 1 principal : GO – charpente métallique dont local technique neuf – bardage - système de protection foudre** | 129d | 2026-10-16 | 2027-04-14 |  | 0d |  |
| 32 | 18.8.1 | Fourniture des Descentes De Charges pour le calcul des renforts nécessaires au renfort structurel et PEO de la structure métallique | 20d | 2026-10-16 | 2026-11-12 | 20 | 49d | 0d |
| 33 | 18.8.2 | Validation MOE des DDC et PEO de la structure métallique | 10d | 2026-11-13 | 2026-11-26 | 32 | 49d | 0d |
| 34 | 18.8.3 | Fourniture des solutions de reprise de structure GO pour descendre les charges aux fondations, des systèmes de renforcement de plancher existant avec saignées et barres HA | 20d | 2026-11-27 | 2026-12-24 | 33 | 69d | 0d |
| 35 | 18.8.4 | Validation MOE des DDC GO et solutions proposées | 10d | 2026-12-25 | 2027-01-07 | 34 | 69d |  |
| 36 | 18.8.5 | Commande, fabrication et acheminement de toute la structure métallique, bardage et couverture ainsi que tout équipement divers nécessaire | 50d | 2026-11-27 | 2027-02-04 | 33 | 49d |  |
| 37 | 18.8.6 | Dépôt du maillage en méplat de cuivre (celui traversant la toiture et celui cheminant sur acrotère) et de l'équipotentialité en T.T. NBT y/c mise en place continuité provisoire | 5d | 2027-01-08 | 2027-01-14 | 23 | 64d |  |
| 38 | 18.8.7 | Création des plots Béton Armé de support de la structure métallique | 5d | 2027-01-29 | 2027-02-04 | 28 | 0d |  |
| 39 | 18.8.8 | Création des renforts de la structure existante pour reprendre la DDC (niveaux en dessous) avec pose de renforts provisoires pour permettre la pose de la structure en T.T. dont la réalisation du renforcement du plancher existant avec saignées et barres HA | 15d | 2027-02-05 | 2027-02-25 | 38 | 0d |  |
| 40 | 18.8.9 | Agrandissement réservation grille de ventilation | 2d | 2027-01-29 | 2027-02-01 | 38SS | 51d | 0d |
| 41 | 18.8.10 | Démolition d'une souche béton | 1d | 2027-02-02 | 2027-02-02 | 40 | 51d |  |
| 42 | 18.8.11 | Mise en protection de l'étanchéité définitive | 2d | 2027-02-25 | 2027-03-01 | 43SF | 33d |  |
| 43 | 18.8.12 | Création d'un local technique neuf (superstructure couverture et bardage) | 15d | 2027-03-01 | 2027-03-19 | 39SS+5d, 30 | 0d |  |
| 44 | 18.8.13 | Pose de la structure porteuse (plancher + caillebotis + GC + escaliers d'accès) | 15d | 2027-03-22 | 2027-04-09 | 43 | 0d |  |
| 45 | 18.8.14 | Pose porte d'accès à la toiture | 1d | 2027-04-12 | 2027-04-12 | 44 | 0d |  |
| 46 | 18.8.15 | Foudre - raccordement définitif | 2d | 2027-04-13 | 2027-04-14 | 45 | 0d |  |
| 47 | 18.9 | **LOT 3 : CVC** | 349d | 2026-10-16 | 2028-03-01 |  | 0d |  |
| 48 | 18.9.1 | **Travaux préparatoires** | 90d | 2026-10-16 | 2027-02-18 |  | 259d |  |
| 49 | 18.9.1.1 | Validation MOE des FT et équipements proposés | 21d | 2026-10-16 | 2026-11-13 | 20 | 286d | 0d |
| 50 | 18.9.1.2 | Commande, fabrication et acheminement de tous les équipements | 42d | 2026-11-16 | 2027-01-12 | 49 | 286d |  |
| 51 | 18.9.1.3 | CVC / TRAVAUX PREPARATOIRES LOCAL CTA R+4 (Arrêt ponctuel VMC et du compresseur d'air comprimé au moment du repositionnement du caisson et du service d'air comprimé) / Installations existantes : remplacement de la panoplie hydraulique / à faire avt GO | 15d | 2026-12-18 | 2027-01-07 | 21FF | 229d | 0d |
| 52 | 18.9.1.4 | CVC / LOCAL CTA ST R+1 / RENOVATION REGULATION ET PANOPLIE HYDRAULIQUE CTA ST1 - Nécessite une coupure ; ST2 reste en fonctionnement | 15d | 2027-01-08 | 2027-01-28 | 51 | 229d | 0d |
| 53 | 18.9.1.5 | CVC / LOCAL CTA ST R+1 / RENOVATION REGULATION ET PANOPLIE HYDRAULIQUE CTA ST2 - Nécessite une coupure ; ST1 reste en fonctionnement | 15d | 2027-01-29 | 2027-02-18 | 52 | 229d | 0d |

| ID | WBS | Task | Duration | Start | Finish | Predecessors | Total slack | Free slack | Constraint |
| --- | --- | --- | --- | --- | --- | --- | --- | --- | --- |
| 54 | 18.9.2 | **PERIODE 2_TRAVAUX CVC NOUVELLE PRODUCTION_7 MOIS (HORS TRAVAUX PREPARATOIRES)** | 255d | 2027-02-19 | 2028-02-24 | 19SS+30d | 4d |  |  |
| 55 | 18.9.2.1 | Mise en place des installations de chantier | 5d | 2027-04-15 | 2027-04-21 | 31 | 0d |  |  |
| 56 | 18.9.2.2 | Mise à disposition et raccordement centrale de location sur réseau eau glacée - NBT | 15d | 2027-02-19 | 2027-03-11 |  | 244d |  | start no earlier than 2027-02-19 |
| 57 | 18.9.2.3 | INTERVENTIONS PREPARATOIRES - Dépose des 2 CTA | 15d | 2027-02-19 | 2027-03-11 |  | 4d | 0d |  |
| 58 | 18.9.2.4 | MAD caissons insufflateurs LOCAL CTA R+4 | 240d | 2027-03-12 | 2028-02-24 | 85FF, 57 | 4d |  |  |
| 59 | 18.9.2.5 | Installation des nouvelles unités de production et des équipements du local ballon y/c gruttage etc. | 25d | 2027-04-15 | 2027-05-19 | 31 | 155d | 0d |  |
| 60 | 18.9.2.6 | Création des départs dans les TGBT NA1 / NA2 et ICA - Consignation des nouveaux départs et tirage des cables à laisser en attente dans le local CTA R+4 | 10d | 2027-02-19 | 2027-03-04 |  | 219d | 0d |  |
| 61 | 18.9.2.7 | Installation électrique en TT, local ballons et local CTA R+4 | 5d | 2027-05-06 | 2027-05-12 | 59SS+15d | 200d |  |  |
| 62 | 18.9.2.8 | Finalisation travaux calorifuge + calfeutrements | 15d | 2027-05-20 | 2027-06-09 | 59 | 155d | 0d |  |
| 63 | 18.9.2.9 | Autres prestations : Extérieur, pied de la tour etc. | 25d | 2027-06-10 | 2027-07-14 | 62 | 155d |  |  |
| 64 | 18.9.2.10 | Rénovation régulation et panoplie hydraulique- Arrêt CTA IFR1, maintien IFR2 | 15d | 2027-03-05 | 2027-03-25 | 60 | 219d | 0d |  |
| 65 | 18.9.2.11 | Rénovation régulation et panoplie hydraulique- Arrêt CTA IFR2, maintien IFR1 | 15d | 2027-03-26 | 2027-04-15 | 64 | 219d |  |  |
| 66 | 18.9.2.12 | Modification régulation pupitre chef salle IFR | 10d | 2027-03-05 | 2027-03-18 | 60 | 239d |  |  |
| 67 | 18.9.2.13 | Dépose décablage CTA double flux / SOUS STATION TWR N-2 | 10d | 2027-04-22 | 2027-05-05 | 55 | 0d |  |  |
| 68 | 18.9.2.14 | MAD caissons insufflateurs et extrateur - install prov. TWR | 75d | 2027-05-06 | 2027-08-18 | 67 | 0d |  |  |
| 69 | 18.9.2.15 | Modification hydraulique de la sous station eau glacée TWR N-2 | 15d | 2027-02-19 | 2027-03-11 | 53 | 229d | 0d |  |
| 70 | 18.9.2.16 | Modification régulation de la sous station eau glacée TWR N-2 | 15d | 2027-03-12 | 2027-04-01 | 69 | 229d |  |  |
| 71 | 18.9.2.17 | Modification hydraulique de la sous station eau chaude TWR N-2 | 15d | 2027-07-01 | 2027-07-21 | 78FS+10d | 0d |  |  |
| 72 | 18.9.2.18 | Modification régulation de la sous station eau chaude TWR N-2 | 20d | 2027-07-22 | 2027-08-18 | 71 | 0d |  |  |
| 73 | 18.9.2.19 | Remplissage eau adoucie / SOUS STATION TWR N-2 | 3d | 2027-03-12 | 2027-03-16 | 69 | 241d |  |  |
| 74 | 18.9.2.20 | Fourniture et pose de la nouvelle Centrale de traitement d'air double flux TWR y compris raccordement hydraulique et aéraulique / SOUS STATION TWR N-2 | 30d | 2027-08-19 | 2027-09-29 | 72 | 0d |  |  |
| 75 | 18.9.2.21 | Régulation et raccordement électrique de la CTA double flux TWR / SOUS STATION TWR N-2 | 20d | 2027-09-30 | 2027-10-27 | 74 | 0d |  |  |
| 76 | 18.9.2.22 | Fourniture et pose des équipements du nouveau local échangeurs à plaques de l'ABT y compris raccordement hydrauliques des équipements / LOCAL ECHANGEURS | 20d | 2027-04-22 | 2027-05-19 | 55 | 185d | 0d |  |
| 77 | 18.9.2.23 | Raccordements électriques du local échangeurs à plaques | 10d | 2027-05-20 | 2027-06-02 | 76 | 185d |  |  |
| 78 | 18.9.2.24 | Rénovation panoplie secondaire echangeurs ACA et raccordements hydrauliques de l'échangeur | 20d | 2027-05-20 | 2027-06-16 | 68SS+10d | 0d |  |  |
| 79 | 18.9.3 | BASCULE ET MISE EN SITUATION DE LA NOUVELLE PRODUCTION | 5d | 2027-10-28 | 2027-11-03 | 75 | 0d |  |  |
| 80 | 18.9.4 | Essais – rinçage – équilibrage | 5d | 2027-11-04 | 2027-11-10 | 79 | 0d |  |  |
| 81 | 18.9.5 | Formation des utilisateurs | 5d | 2027-11-11 | 2027-11-17 | 80 | 0d |  |  |
| 82 | 18.9.6 | MESO - durée un mois minimum | 20d | 2027-11-18 | 2027-12-15 | 81 | 0d |  |  |

| ID | WBS | Task | Type | Duration | Start | Finish | Predecessors | Total slack | Free slack | Constraint |
| --- | --- | --- | --- | --- | --- | --- | --- | --- | --- | --- |
| 83 | 18.9.7 | **PERIODE 3_TRAVAUX DEPOSE ANCIENNE INSTALLATION CVC** |  | 45d | 2027-12-16 | 2028-03-01 | 82 | 0d |  |  |
| 84 | 18.9.7.1 | Interventions préparatoires - dépose des réseaux hydrauliques obsolètes / LOCAL CTA R+4 |  | 5d | 2027-12-16 | 2028-01-05 | 82 | 0d |  |  |
| 85 | 18.9.7.2 | Fourniture et pose de la nouvelle CTA double flux NBT y compris, gainages, raccordements hydrauliques / LOCAL CTA R+4 |  | 15d | 2028-01-06 | 2028-01-26 | 84 | 0d |  |  |
| 86 | 18.9.7.3 | Raccordements électriques de la CTA double flux NBT / LOCAL CTA R+4 |  | 5d | 2028-01-27 | 2028-02-02 | 85 | 0d |  |  |
| 87 | 18.9.7.4 | Raccordement 2 ème branche inverseur de source TFP sur TGBT / LOCAL CTA R+4 |  | 5d | 2028-02-03 | 2028-02-09 | 86 | 0d |  |  |
| 88 | 18.9.7.5 | Dépose des installations existantes obsolètes / TOITURE TERRASSE ABT |  | 5d | 2028-02-10 | 2028-02-16 | 87 | 0d |  |  |
| 89 | 18.9.7.6 | Finalisation travaux dans local CTA R+4 |  | 5d | 2028-02-17 | 2028-02-23 | 88 | 0d |  |  |
| 90 | 18.9.7.7 | Repli des installations de chantier |  | 5d | 2028-02-24 | 2028-03-01 | 89 | 0d |  |  |
| 91 | 19 | Trêve aéroportuaire - plus de consignation possible entre le 15/04/27 et le 15/10/27 |  | 132d | 2027-04-15 | 2027-10-15 |  | 88d |  | start no earlier than 2027-04-15 |
| 92 | 20 | OPR - GO / Couverture |  | 15d | 2027-04-15 | 2027-05-05 | 46 | 205d | 0d |  |
| 93 | 21 | Réception - GO / couverture | milestone | 0d | 2027-05-05 | 2027-05-05 | 92 | 205d |  |  |
| 94 | 22 | Réception - CVC | milestone | 0d | 2027-12-15 | 2027-12-15 | 82 | 45d |  |  |
